# Riverbend WTP Upgrade - Update 05 (Sample Project)

How a schedule from MS Project changed from version to version. A marks actual dates.

## Version 1 (data date 2026-07-31, saved 2026-09-07, file PathProof Example Project.mpp)

| ID | WBS | Task | Duration | Start | Finish | Predecessors | Complete | Total float | Constraint |
| --- | --- | --- | --- | --- | --- | --- | --- | --- | --- |
| 1 | 1 | **1 PROJECT INITIATION** | 15d? | 2026-03-02 A | 2026-03-20 |  | 87% | 235d |  |
| 2 |  | Notice to proceed | 0d? | 2026-03-02 A | 2026-03-02 A |  | 100% |  | must start on 2026-03-02 |
| 3 |  | Mobilise site facilities | 10d? | 2026-03-02 A | 2026-03-13 A | 2 | 100% |  |  |
| 4 |  | Baseline schedule approved | 8d? | 2026-03-02 A | 2026-03-11 A | 2 | 100% |  |  |
| 5 |  | Site survey and geotech verification | 12d? | 2026-03-04 A | 2026-03-19 A | 3SS+2d | 100% |  |  |
| 6 |  | Permits and consents confirmed | 15d? | 2026-03-02 A | 2026-03-20 | 2 | 60% | 235d |  |
| 7 | 2 | **2 DETAILED DESIGN** | 55d? | 2026-03-20 A | 2026-06-04 A |  | 100% |  |  |
| 8 |  | Process design report | 23d? | 2026-03-20 A | 2026-04-21 A | 4, 5 | 100% |  |  |
| 9 |  | Civil and structural design | 29d? | 2026-03-27 A | 2026-05-06 A | 8SS+5d | 100% |  |  |
| 10 |  | Mechanical design | 22d? | 2026-04-01 A | 2026-04-30 A | 8SS+8d | 100% |  |  |
| 11 |  | Electrical and controls design | 24d? | 2026-04-08 A | 2026-05-11 A | 10SS+5d | 100% |  |  |
| 12 |  | HAZOP workshop and close-out | 8d? | 2026-05-12 A | 2026-05-21 A | 9, 10, 11 | 100% |  |  |
| 13 |  | Issued for construction drawings | 10d? | 2026-05-22 A | 2026-06-04 A | 12 | 100% |  |  |
| 14 |  | Design review milestone | 0d? | 2026-05-21 A | 2026-05-21 A | 12 | 100% |  |  |
| 15 | 3 | **3 PROCUREMENT** | 121d? | 2026-03-02 A | 2026-08-17 |  | 91% | 129d |  |
| 16 |  | Membrane skid supply contract | 12d? | 2026-04-22 A | 2026-05-07 A | 8 | 100% |  |  |
| 17 |  | Membrane skids fabrication and delivery | 72d? | 2026-05-08 A | 2026-08-17 | 16 | 83% | 39d |  |
| 18 |  | Blowers and pumps procurement | 45d? | 2026-05-01 A | 2026-07-02 A | 10 | 100% |  |  |
| 19 |  | Switchboard and VSD procurement | 50d? | 2026-05-12 A | 2026-07-20 A | 11 | 100% |  |  |
| 20 |  | Instrumentation package | 35d? | 2026-05-12 A | 2026-06-29 A | 11 | 100% |  |  |
| 21 |  | Spare parts and consumables order | 20d? | 2026-03-02 A | 2026-03-27 |  | 60% | 230d |  |
| 22 | 4 | **4 CIVIL WORKS** | 91d? | 2026-06-05 A | 2026-10-09 |  | 54% | 90d |  |
| 23 |  | Bulk earthworks | 19d? | 2026-06-05 A | 2026-07-01 A | 13 | 100% |  |  |
| 24 |  | Piling for process building | 17d? | 2026-07-02 A | 2026-07-24 A | 23 | 100% |  |  |
| 25 |  | Membrane building foundations | 18d? | 2026-07-29 A | 2026-08-21 | 24FS+2d | 11% | -1d |  |
| 26 |  | Process building slab and columns | 20d? | 2026-08-24 | 2026-09-18 | 25 |  | -1d |  |
| 27 |  | Clearwater tank construction | 36d? | 2026-07-09 A | 2026-08-27 | 23FS+5d | 44% | 107d |  |
| 28 |  | Interconnecting pipework trenching | 18d? | 2026-07-02 A | 2026-07-27 A | 23 | 100% |  |  |
| 29 |  | Roads and hardstands | 15d? | 2026-07-14 A | 2026-08-03 | 28FF+5d | 87% | 139d |  |
| 30 |  | Process building roof and cladding | 15d? | 2026-09-21 | 2026-10-09 | 26 |  | -1d |  |
| 31 |  | Civil works complete | 0d? | 2026-10-09 | 2026-10-09 | 30, 27, 29 |  | 90d |  |
| 32 | 5 | **5 MECHANICAL INSTALLATION** | 104.7d? | 2026-06-19 A | 2026-11-12 |  | 25% | 66.3d |  |
| 33 |  | Membrane skids installation | 15d? | 2026-10-12 | 2026-10-30 | 17, 30 |  | 0d |  |
| 34 |  | Blowers and pumps installation | 12d? | 2026-10-12 | 2026-10-27 | 18, 30 |  | 68d |  |
| 35 |  | Process pipework fabrication | 25d? | 2026-06-19 A | 2026-07-23 | 13FS+10d | 85% | 61d |  |
| 36 |  | Process pipework installation | 22d? | 2026-07-24 A | 2026-11-12 | 35, 33SS+5d | 15% | 66.3d |  |
| 37 |  | Tank mechanical fit-out | 14d? | 2026-08-28 | 2026-09-16 | 27 |  | 107d |  |
| 38 |  | Chemical dosing skids install | 10d? | 2026-10-28 | 2026-11-10 | 34 |  | 68d |  |
| 39 |  | Mechanical completion | 0d? | 2026-11-12 | 2026-11-12 | 36, 37, 38 |  | 66.3d |  |
| 40 | 6 | **6 ELECTRICAL AND CONTROLS** | 83d? | 2026-08-05 A | 2026-11-27 |  | 2% | 55d |  |
| 41 |  | Switchboard installation | 10d? | 2026-10-12 | 2026-10-23 | 19, 30 |  | -1d |  |
| 42 |  | Cable tray and cabling | 20d? | 2026-10-15 | 2026-11-11 | 41SS+3d |  | -1d |  |
| 43 |  | Field instrumentation installation | 15d? | 2026-08-05 | 2026-08-25 | 20, 36SS+8d |  | 55d |  |
| 44 |  | SCADA configuration | 25d? | 2026-08-05 A | 2026-09-08 | 11FS+15d | 5% | 48d |  |
| 45 |  | Loop testing | 12d? | 2026-11-12 | 2026-11-27 | 42, 43, 44FS-3d |  | -1d |  |
| 46 |  | Electrical completion | 0d? | 2026-11-27 | 2026-11-27 | 45 |  | 55d |  |
| 47 | 7 | **7 COMMISSIONING AND HANDOVER** | 55d? | 2026-11-30 | 2027-02-12 |  |  | -1d |  |
| 48 |  | Pre-commissioning checks | 10d? | 2026-11-30 | 2026-12-11 | 45 |  | -1d |  |
| 49 |  | Water commissioning | 15d? | 2026-12-14 | 2027-01-01 | 48 |  | -1d |  |
| 50 |  | Process proving and performance test | 20d? | 2027-01-04 | 2027-01-29 | 49 |  | -1d |  |
| 51 |  | Operator training | 8d? | 2026-12-21 | 2026-12-30 | 49SS+5d |  | 21d |  |
| 52 |  | As-built documentation | 12d? | 2027-01-04 | 2027-01-19 | 50SS |  | 18d |  |
| 53 |  | Defects close-out | 10d? | 2027-02-01 | 2027-02-12 | 50 |  | 0d |  |
| 54 |  | SUBSTANTIAL COMPLETION | 0d? | 2027-01-29 | 2027-01-29 | 50, 51 |  | -1d | must finish on 2027-01-29 |
| 55 |  | Final handover | 0d? | 2027-02-12 | 2027-02-12 | 52, 53 |  | 0d |  |

## Version 2 (data date 2026-08-28, saved 2026-09-07, file PathProof Example Project - Updated.mpp)

Last finish 2027-02-12 → 2027-02-22 (+10d). Complete tasks 18 → 21.

Changed:

| ID | Task | Start | Finish | Duration | Complete | Total float | Predecessors | Other |
| --- | --- | --- | --- | --- | --- | --- | --- | --- |
| 15 | **3 PROCUREMENT** |  | 2026-08-17 → 2026-08-31 (+14d) | 121d? → 131d? | 91% → 96% | 129d → 125d |  |  |
| 17 | Membrane skids fabrication and delivery |  | 2026-08-17 → 2026-08-31 (+14d) | 72d? → 82d? | 83% → 98% | 39d → 35d |  |  |
| 19 | Switchboard and VSD procurement |  | 2026-07-20 A → 2026-07-30 A (+10d) | 50d? → 58d? |  |  |  |  |
| 22 | **4 CIVIL WORKS** |  | 2026-10-09 → 2026-10-19 (+10d) | 91d? → 97d? | 54% → 77% |  |  |  |
| 25 | Membrane building foundations |  | 2026-08-21 A |  | 11% → 100% | -1d → none |  |  |
| 26 | Process building slab and columns | 2026-08-24 A | 2026-09-18 → 2026-09-28 (+10d) | 20d? → 26d? | 0% → 15% | -1d → 0d |  |  |
| 27 | Clearwater tank construction |  | 2026-08-27 A |  | 44% → 100% | 107d → none |  |  |
| 29 | Roads and hardstands |  | 2026-08-03 A |  | 87% → 100% | 139d → none |  |  |
| 30 | Process building roof and cladding | 2026-09-21 → 2026-09-29 (+8d) | 2026-10-09 → 2026-10-19 (+10d) |  |  | -1d → 0d |  |  |
| 31 | Civil works complete | 2026-10-09 → 2026-10-19 (+10d) | 2026-10-09 → 2026-10-19 (+10d) |  |  |  |  |  |
| 32 | **5 MECHANICAL INSTALLATION** |  | 2026-11-12 → 2026-11-26 (+14d) | 104.7d? → 114.95d? |  | 66.3d → 62.05d |  |  |
| 33 | Membrane skids installation | 2026-10-12 → 2026-10-20 (+8d) | 2026-10-30 → 2026-11-09 (+10d) |  |  |  |  |  |
| 34 | Blowers and pumps installation | 2026-10-12 → 2026-10-20 (+8d) | 2026-10-27 → 2026-11-04 (+8d) |  |  | 68d → 1d |  |  |
| 36 | Process pipework installation | 2026-07-24 A → 2026-08-21 A (+28d) | 2026-11-12 → 2026-11-26 (+14d) | 22d? → 27d? |  | 66.3d → 62.05d |  |  |
| 38 | Chemical dosing skids install | 2026-10-28 → 2026-11-05 (+8d) | 2026-11-10 → 2026-11-18 (+8d) |  |  | 68d → 1d |  |  |
| 39 | Mechanical completion | 2026-11-12 → 2026-11-26 (+14d) | 2026-11-12 → 2026-11-26 (+14d) |  |  | 66.3d → 62.05d |  |  |
| 40 | **6 ELECTRICAL AND CONTROLS** | 2026-08-05 A → 2026-09-02 A (+28d) | 2026-11-27 → 2026-12-07 (+10d) | 83d? → 69d? |  |  |  |  |
| 41 | Switchboard installation | 2026-10-12 → 2026-10-20 (+8d) | 2026-10-23 → 2026-11-02 (+10d) |  |  | -1d → 0d |  |  |
| 42 | Cable tray and cabling | 2026-10-15 → 2026-10-23 (+8d) | 2026-11-11 → 2026-11-19 (+8d) |  |  | -1d → 0d |  |  |
| 43 | Field instrumentation installation | 2026-08-05 → 2026-09-02 (+28d) | 2026-08-25 → 2026-09-22 (+28d) |  |  | 55d → 42d |  |  |
| 44 | SCADA configuration | 2026-08-05 A → 2026-09-02 A (+28d) | 2026-09-08 → 2026-10-14 (+36d) | 25d? → 31d? |  | 48d → 29d |  |  |
| 45 | Loop testing | 2026-11-12 → 2026-11-20 (+8d) | 2026-11-27 → 2026-12-07 (+10d) |  |  | -1d → 0d | 42, 43, 44FS-3d → 42, 43, 44FS-3d, 38 |  |
| 46 | Electrical completion | 2026-11-27 → 2026-12-07 (+10d) | 2026-11-27 → 2026-12-07 (+10d) |  |  |  |  |  |
| 47 | **7 COMMISSIONING AND HANDOVER** | 2026-11-30 → 2026-12-08 (+8d) | 2027-02-12 → 2027-02-22 (+10d) |  |  | -1d → 0d |  | baseline finish 2027-02-08 → 2027-02-12 |
| 48 | Pre-commissioning checks | 2026-11-30 → 2026-12-08 (+8d) | 2026-12-11 → 2026-12-21 (+10d) |  |  | -1d → 0d |  |  |
| 49 | Water commissioning | 2026-12-14 → 2026-12-22 (+8d) | 2027-01-01 → 2027-01-11 (+10d) |  |  | -1d → 0d |  |  |
| 50 | Process proving and performance test | 2027-01-04 → 2027-01-12 (+8d) | 2027-01-29 → 2027-02-08 (+10d) |  |  | -1d → 0d |  |  |
| 51 | Operator training | 2026-12-21 → 2026-12-29 (+8d) | 2026-12-30 → 2027-01-07 (+8d) |  |  | 21d → 25d |  |  |
| 52 | As-built documentation | 2027-01-04 → 2027-01-12 (+8d) | 2027-01-19 → 2027-01-27 (+8d) |  |  |  |  |  |
| 53 | Defects close-out | 2027-02-01 → 2027-02-09 (+8d) | 2027-02-12 → 2027-02-22 (+10d) |  |  |  |  |  |
| 54 | SUBSTANTIAL COMPLETION | 2027-01-29 → 2027-02-12 (+14d) | 2027-01-29 → 2027-02-12 (+14d) |  |  | -1d → 0d |  | constraint must finish on 2027-01-29 → must finish on 2027-02-12; baseline start 2027-01-29 → 2027-02-12; baseline finish 2027-01-29 → 2027-02-12 |
| 55 | Final handover | 2027-02-12 → 2027-02-22 (+10d) | 2027-02-12 → 2027-02-22 (+10d) |  |  |  |  |  |
