# RIVERBENDWTP

How a schedule from Primavera P6 changed from version to version. A marks actual dates.

## Version 1 (data date 2026-07-31, saved 2026-07-31, file PathProof Example Project.xer)

| ID | WBS | Task | Duration | Start | Finish | Predecessors | Complete | Total float | Constraint |
| --- | --- | --- | --- | --- | --- | --- | --- | --- | --- |
|  |  | **Riverbend WTP Upgrade - Update 05 (Sample Project)** |  | 2026-03-02 | 2027-02-12 |  |  |  |  |
|  | 1 | **1 PROJECT INITIATION** |  | 2026-03-02 | 2026-03-20 |  |  |  |  |
| A2 |  | Notice to proceed | 0d | 2026-03-02 A | 2026-03-02 A |  | 100% |  | mandatory start 2026-03-02 |
| A3 |  | Mobilise site facilities | 10d | 2026-03-02 A | 2026-03-13 A | A2 | 100% |  |  |
| A4 |  | Baseline schedule approved | 8d | 2026-03-02 A | 2026-03-11 A | A2 | 100% |  |  |
| A6 |  | Permits and consents confirmed | 15d | 2026-03-02 A | 2026-03-20 | A2 | 60% | 235d |  |
| A5 |  | Site survey and geotech verification | 12d | 2026-03-04 A | 2026-03-19 A | A3 SS+2d | 100% |  |  |
|  | 2 | **2 DETAILED DESIGN** |  | 2026-03-20 | 2026-06-04 |  |  |  |  |
| A8 |  | Process design report | 23d | 2026-03-20 A | 2026-04-21 A | A4, A5 | 100% |  |  |
| A9 |  | Civil and structural design | 29d | 2026-03-27 A | 2026-05-06 A | A8 SS+5d | 100% |  |  |
| A10 |  | Mechanical design | 22d | 2026-04-01 A | 2026-04-30 A | A8 SS+8d | 100% |  |  |
| A11 |  | Electrical and controls design | 24d | 2026-04-08 A | 2026-05-11 A | A10 SS+5d | 100% |  |  |
| A12 |  | HAZOP workshop and close-out | 8d | 2026-05-12 A | 2026-05-21 A | A9, A10, A11 | 100% |  |  |
| A14 |  | Design review milestone | 0d | 2026-05-21 A | 2026-05-21 A | A12 | 100% |  |  |
| A13 |  | Issued for construction drawings | 10d | 2026-05-22 A | 2026-06-04 A | A12 | 100% |  |  |
|  | 3 | **3 PROCUREMENT** |  | 2026-03-02 | 2026-08-17 |  |  |  |  |
| A21 |  | Spare parts and consumables order | 20d | 2026-03-02 A | 2026-03-27 |  | 60% | 230d |  |
| A16 |  | Membrane skid supply contract | 12d | 2026-04-22 A | 2026-05-07 A | A8 | 100% |  |  |
| A18 |  | Blowers and pumps procurement | 45d | 2026-05-01 A | 2026-07-02 A | A10 | 100% |  |  |
| A17 |  | Membrane skids fabrication and delivery | 72d | 2026-05-08 A | 2026-08-17 | A16 | 83% | 39d |  |
| A19 |  | Switchboard and VSD procurement | 50d | 2026-05-12 A | 2026-07-20 A | A11 | 100% |  |  |
| A20 |  | Instrumentation package | 35d | 2026-05-12 A | 2026-06-29 A | A11 | 100% |  |  |
|  | 4 | **4 CIVIL WORKS** |  | 2026-06-05 | 2026-10-09 |  |  |  |  |
| A23 |  | Bulk earthworks | 19d | 2026-06-05 A | 2026-07-01 A | A13 | 100% |  |  |
| A24 |  | Piling for process building | 17d | 2026-07-02 A | 2026-07-24 A | A23 | 100% |  |  |
| A28 |  | Interconnecting pipework trenching | 18d | 2026-07-02 A | 2026-07-27 A | A23 | 100% |  |  |
| A27 |  | Clearwater tank construction | 36d | 2026-07-09 A | 2026-08-27 | A23 FS+5d | 44% | 107d |  |
| A29 |  | Roads and hardstands | 15d | 2026-07-14 A | 2026-08-03 | A28 FF+5d | 87% | 139d |  |
| A25 |  | Membrane building foundations | 18d | 2026-07-29 A | 2026-08-21 | A24 FS+2d | 11% | -1d |  |
| A26 |  | Process building slab and columns | 20d | 2026-08-24 | 2026-09-18 | A25 |  | -1d |  |
| A30 |  | Process building roof and cladding | 15d | 2026-09-21 | 2026-10-09 | A26 |  | -1d |  |
| A31 |  | Civil works complete | 0d | 2026-10-09 | 2026-10-09 | A30, A27, A29 |  | 90d |  |
|  | 5 | **5 MECHANICAL INSTALLATION** |  | 2026-06-19 | 2026-11-12 |  |  |  |  |
| A35 |  | Process pipework fabrication | 25d | 2026-06-19 A | 2026-07-23 | A13 FS+10d | 85% | 61d |  |
| A36 |  | Process pipework installation | 22d | 2026-07-24 A | 2026-11-12 | A35, A33 SS+5d | 15% | 66.3d |  |
| A37 |  | Tank mechanical fit-out | 14d | 2026-08-28 | 2026-09-16 | A27 |  | 107d |  |
| A33 |  | Membrane skids installation | 15d | 2026-10-12 | 2026-10-30 | A17, A30 |  | 0d |  |
| A34 |  | Blowers and pumps installation | 12d | 2026-10-12 | 2026-10-27 | A18, A30 |  | 68d |  |
| A38 |  | Chemical dosing skids install | 10d | 2026-10-28 | 2026-11-10 | A34 |  | 68d |  |
| A39 |  | Mechanical completion | 0d | 2026-11-12 | 2026-11-12 | A36, A37, A38 |  | 66.3d |  |
|  | 6 | **6 ELECTRICAL AND CONTROLS** |  | 2026-08-05 | 2026-11-27 |  |  |  |  |
| A44 |  | SCADA configuration | 25d | 2026-08-05 A | 2026-09-08 | A11 FS+15d | 5% | 48d |  |
| A43 |  | Field instrumentation installation | 15d | 2026-08-05 | 2026-08-25 | A20, A36 SS+8d |  | 55d |  |
| A41 |  | Switchboard installation | 10d | 2026-10-12 | 2026-10-23 | A19, A30 |  | -1d |  |
| A42 |  | Cable tray and cabling | 20d | 2026-10-15 | 2026-11-11 | A41 SS+3d |  | -1d |  |
| A45 |  | Loop testing | 12d | 2026-11-12 | 2026-11-27 | A42, A43, A44 FS-3d |  | -1d |  |
| A46 |  | Electrical completion | 0d | 2026-11-27 | 2026-11-27 | A45 |  | 55d |  |
|  | 7 | **7 COMMISSIONING AND HANDOVER** |  | 2026-11-30 | 2027-02-12 |  |  |  |  |
| A48 |  | Pre-commissioning checks | 10d | 2026-11-30 | 2026-12-11 | A45 |  | -1d |  |
| A49 |  | Water commissioning | 15d | 2026-12-14 | 2027-01-01 | A48 |  | -1d |  |
| A51 |  | Operator training | 8d | 2026-12-21 | 2026-12-30 | A49 SS+5d |  | 21d |  |
| A50 |  | Process proving and performance test | 20d | 2027-01-04 | 2027-01-29 | A49 |  | -1d |  |
| A52 |  | As-built documentation | 12d | 2027-01-04 | 2027-01-19 | A50 SS |  | 18d |  |
| A54 |  | SUBSTANTIAL COMPLETION | 0d | 2027-01-29 | 2027-01-29 | A50, A51 |  | -1d | mandatory finish 2027-01-29 |
| A53 |  | Defects close-out | 10d | 2027-02-01 | 2027-02-12 | A50 |  | 0d |  |
| A55 |  | Final handover | 0d | 2027-02-12 | 2027-02-12 | A52, A53 |  | 0d |  |

## Version 2 (data date 2026-08-28, saved 2026-08-28, file PathProof Example Project - Updated.xer)

Last finish 2027-02-12 → 2027-02-22 (+10d). Complete tasks 18 → 21.

Changed:

| ID | Task | Start | Finish | Duration | Complete | Total float | Predecessors | Other |
| --- | --- | --- | --- | --- | --- | --- | --- | --- |
|  | **Riverbend WTP Upgrade - Update 06 (Sample Project)** |  | 2027-02-12 → 2027-02-22 (+10d) |  |  |  |  | was named Riverbend WTP Upgrade - Update 05 (Sample Project) |
| 3 | **3 PROCUREMENT** |  | 2026-08-17 → 2026-08-31 (+14d) |  |  |  |  |  |
| A17 | Membrane skids fabrication and delivery |  | 2026-08-17 → 2026-08-31 (+14d) | 72d → 82d | 83% → 98% | 39d → 35d |  | resources Procurement [576 h] → Procurement [656 h] |
| A19 | Switchboard and VSD procurement |  | 2026-07-20 A → 2026-07-30 A (+10d) | 50d → 58d |  |  |  | resources Procurement [400 h] → Procurement [464 h] |
| 4 | **4 CIVIL WORKS** |  | 2026-10-09 → 2026-10-19 (+10d) |  |  |  |  |  |
| A27 | Clearwater tank construction |  | 2026-08-27 A |  | 44% → 100% | 107d → none |  |  |
| A29 | Roads and hardstands |  | 2026-08-03 A |  | 87% → 100% | 139d → none |  |  |
| A25 | Membrane building foundations |  | 2026-08-21 A |  | 11% → 100% | -1d → none |  |  |
| A26 | Process building slab and columns | 2026-08-24 A | 2026-09-18 → 2026-09-28 (+10d) | 20d → 26d | 0% → 15% | -1d → 0d |  | resources Civil Crew B [160 h] → Civil Crew B [208 h] |
| A30 | Process building roof and cladding | 2026-09-21 → 2026-09-29 (+8d) | 2026-10-09 → 2026-10-19 (+10d) |  |  | -1d → 0d |  |  |
| A31 | Civil works complete | 2026-10-09 → 2026-10-19 (+10d) | 2026-10-09 → 2026-10-19 (+10d) |  |  |  |  |  |
| 5 | **5 MECHANICAL INSTALLATION** |  | 2026-11-12 → 2026-11-26 (+14d) |  |  |  |  |  |
| A36 | Process pipework installation | 2026-07-24 A → 2026-08-21 A (+28d) | 2026-11-12 → 2026-11-26 (+14d) | 22d → 27d |  | 66.3d → 62.05d |  | resources Mechanical Crew [176 h] → Mechanical Crew [216 h] |
| A33 | Membrane skids installation | 2026-10-12 → 2026-10-20 (+8d) | 2026-10-30 → 2026-11-09 (+10d) |  |  |  |  |  |
| A34 | Blowers and pumps installation | 2026-10-12 → 2026-10-20 (+8d) | 2026-10-27 → 2026-11-04 (+8d) |  |  | 68d → 1d |  |  |
| A38 | Chemical dosing skids install | 2026-10-28 → 2026-11-05 (+8d) | 2026-11-10 → 2026-11-18 (+8d) |  |  | 68d → 1d |  |  |
| A39 | Mechanical completion | 2026-11-12 → 2026-11-26 (+14d) | 2026-11-12 → 2026-11-26 (+14d) |  |  | 66.3d → 62.05d |  |  |
| 6 | **6 ELECTRICAL AND CONTROLS** | 2026-08-05 → 2026-09-02 (+28d) | 2026-11-27 → 2026-12-07 (+10d) |  |  |  |  |  |
| A44 | SCADA configuration | 2026-08-05 A → 2026-09-02 A (+28d) | 2026-09-08 → 2026-10-14 (+36d) | 25d → 31d |  | 48d → 29d |  | resources Electrical Crew [200 h] → Electrical Crew [248 h] |
| A43 | Field instrumentation installation | 2026-08-05 → 2026-09-02 (+28d) | 2026-08-25 → 2026-09-22 (+28d) |  |  | 55d → 42d |  |  |
| A41 | Switchboard installation | 2026-10-12 → 2026-10-20 (+8d) | 2026-10-23 → 2026-11-02 (+10d) |  |  | -1d → 0d |  |  |
| A42 | Cable tray and cabling | 2026-10-15 → 2026-10-23 (+8d) | 2026-11-11 → 2026-11-19 (+8d) |  |  | -1d → 0d |  |  |
| A45 | Loop testing | 2026-11-12 → 2026-11-20 (+8d) | 2026-11-27 → 2026-12-07 (+10d) |  |  | -1d → 0d | A42, A43, A44 FS-3d → A42, A43, A44 FS-3d, A38 |  |
| A46 | Electrical completion | 2026-11-27 → 2026-12-07 (+10d) | 2026-11-27 → 2026-12-07 (+10d) |  |  |  |  |  |
| 7 | **7 COMMISSIONING AND HANDOVER** | 2026-11-30 → 2026-12-08 (+8d) | 2027-02-12 → 2027-02-22 (+10d) |  |  |  |  |  |
| A48 | Pre-commissioning checks | 2026-11-30 → 2026-12-08 (+8d) | 2026-12-11 → 2026-12-21 (+10d) |  |  | -1d → 0d |  |  |
| A49 | Water commissioning | 2026-12-14 → 2026-12-22 (+8d) | 2027-01-01 → 2027-01-11 (+10d) |  |  | -1d → 0d |  |  |
| A51 | Operator training | 2026-12-21 → 2026-12-29 (+8d) | 2026-12-30 → 2027-01-07 (+8d) |  |  | 21d → 25d |  |  |
| A50 | Process proving and performance test | 2027-01-04 → 2027-01-12 (+8d) | 2027-01-29 → 2027-02-08 (+10d) |  |  | -1d → 0d |  |  |
| A52 | As-built documentation | 2027-01-04 → 2027-01-12 (+8d) | 2027-01-19 → 2027-01-27 (+8d) |  |  |  |  |  |
| A53 | Defects close-out | 2027-02-01 → 2027-02-09 (+8d) | 2027-02-12 → 2027-02-22 (+10d) |  |  |  |  |  |
| A54 | SUBSTANTIAL COMPLETION | 2027-01-29 → 2027-02-12 (+14d) | 2027-01-29 → 2027-02-12 (+14d) |  |  | -1d → 0d |  | constraint mandatory finish 2027-01-29 → mandatory finish 2027-02-12 |
| A55 | Final handover | 2027-02-12 → 2027-02-22 (+10d) | 2027-02-12 → 2027-02-22 (+10d) |  |  |  |  |  |
